# kritican put

Schedule from MS Project, 2003-06-12 to 2005-05-10.
Home

## Calendars

- Standard: Mon-Fri 08:00-12:00, 13:00-17:00; Sat-Sun off.

## Schedule

| ID | Task | Duration | Start | Finish | Predecessors | Total slack | Free slack | Constraint |
| --- | --- | --- | --- | --- | --- | --- | --- | --- |
| 1 | Pripremni radovi | 8d | 2003-06-12 | 2003-06-23 |  | 0d |  | start no earlier than 2003-06-12 |
| 2 | Iskop useka | 15d | 2003-06-24 | 2003-07-14 | 1 | 0d |  |  |
| 3 | Organizacija gradilišta | 7d | 2003-07-01 | 2003-07-09 | 2SS+5d | 3d |  |  |
| 4 | Iskop temelja prvog stuba | 20d | 2003-07-15 | 2003-08-11 | 3, 2 | 0d |  |  |
| 5 | Iskop temelja drugog stuba | 27d | 2003-08-12 | 2003-09-17 | 4 | 47d | 0d |  |
| 6 | Iskop temelja trećeg stuba | 27d | 2003-09-18 | 2003-10-24 | 5 | 101d | 0d |  |
| 7 | Iskop temelja četvrtog stuba | 20d | 2003-10-27 | 2003-11-21 | 6 | 158d | 38d |  |
| 8 | Izrada temelja prvog stuba | 40d | 2003-08-12 | 2003-10-06 | 4 | 0d |  |  |
| 9 | Izrada temelja drugog stuba | 36d | 2003-10-07 | 2003-11-25 | 5, 8 | 34d | 0d |  |
| 10 | Izrada temelja trećeg stuba | 36d | 2003-11-26 | 2004-01-14 | 6, 9 | 79d | 0d |  |
| 11 | Izrada temelja četvrtog stuba | 40d | 2004-01-15 | 2004-03-10 | 7, 10 | 120d |  |  |
| 12 | Izrada prvog stuba | 70d | 2003-10-07 | 2004-01-12 | 8 | 0d |  |  |
| 13 | Izrada drugog stuba | 81d | 2004-01-13 | 2004-05-04 | 9, 12 | 0d |  |  |
| 14 | Izrada trećeg stuba | 81d | 2004-05-05 | 2004-08-25 | 10, 13 | 0d |  |  |
| 15 | Izrada četvrtog stuba | 70d | 2004-08-26 | 2004-12-01 | 11, 14 | 0d |  |  |
| 16 | Izrada prvog kolovoznog nosača | 19d | 2003-07-22 | 2003-08-15 | 4SS+5d | 250d | 0d |  |
| 17 | Izrada drugog kolovoznog nosača | 19d | 2003-08-18 | 2003-09-11 | 16 | 269d | 0d |  |
| 18 | Izrada trećeg kolovoznog nosača | 19d | 2003-09-12 | 2003-10-08 | 17 | 288d | 0d |  |
| 19 | Prednaprezanje prvog kolovoznog nosača | 2d | 2003-09-25 | 2003-09-26 | 16FS+28d | 250d | 0d |  |
| 20 | Prednaprezanje drugog kolovoznog nosača | 2d | 2003-10-22 | 2003-10-23 | 17FS+28d, 19 | 269d | 0d |  |
| 21 | Prednaprezanje trećeg kolovoznog nosača | 2d | 2003-11-18 | 2003-11-19 | 18FS+28d, 20 | 288d | 0d |  |
| 22 | Dopremanje prvog nosača na gradilište | 1d | 2003-10-10 | 2003-10-10 | 19FS+9d | 250d | 18d |  |
| 23 | Dopremanje drugog nosača na gradilište | 1d | 2003-11-06 | 2003-11-06 | 20FS+9d, 22 | 269d | 18d |  |
| 24 | Dopremanje trećeg nosača na gradilište | 1d | 2003-12-03 | 2003-12-03 | 21FS+9d, 23 | 288d |  |  |
| 25 | Montiranje prvog kolovoznog nosača | 10d | 2004-06-14 | 2004-06-25 | 13FS+28d, 22 | 75d | 0d |  |
| 26 | Montiranje drugog kolovoznog nosača | 10d | 2004-10-05 | 2004-10-18 | 14FS+28d, 23, 25 | 32d | 0d |  |
| 27 | Montiranje trećeg kolovoznog nosača | 10d | 2005-01-11 | 2005-01-24 | 15FS+28d, 24, 26 | 0d |  |  |
| 28 | Izrada kolovozne ploče prvog polja | 38d | 2004-06-28 | 2004-08-18 | 25 | 75d | 43d |  |
| 29 | Izrada kolovozne ploče drugog polja | 38d | 2004-10-19 | 2004-12-09 | 26, 28 | 32d |  |  |
| 30 | Izrada kolovozne ploče trećeg polja | 38d | 2005-01-25 | 2005-03-17 | 27, 29 | 0d |  |  |
| 31 | Montaža ograde | 10d | 2005-03-17 | 2005-03-30 | 30FF+9d | 16d |  |  |
| 32 | Asfaltiranje kolovoza | 10d | 2005-04-08 | 2005-04-21 | 30FS+15d | 0d |  |  |
| 33 | Završni radovi | 4d | 2005-04-22 | 2005-04-27 | 32, 31 | 0d |  |  |
| 34 | Tehnički pregled | 9d | 2005-04-28 | 2005-05-10 | 33 | 0d |  |  |
