# Project1-Novak.mpp-Vezba 1

Schedule from MS Project, 2006-06-01 to 2007-04-27.
GRF

## Calendars

- Standard: Mon-Fri 08:00-12:00, 13:00-17:00; Sat-Sun off.

## Schedule

| ID | Task | Duration | Start | Finish | Predecessors | Total slack | Free slack |
| --- | --- | --- | --- | --- | --- | --- | --- |
| 1 | Formiranje gradilista | 5d | 2006-06-01 | 2006-06-07 |  | 0d |  |
| 2 | Siroki iskop za temeljnu plocu | 3d | 2006-06-08 | 2006-06-12 | 1 | 0d |  |
| 3 | Izrada tampon sloja | 1d | 2006-06-13 | 2006-06-13 | 2 | 0d |  |
| 4 | Izrada sloja mrsavog betona | 1d | 2006-06-14 | 2006-06-14 | 3 | 0d |  |
| 5 | Postavljanje hidroizolacije | 1d | 2006-06-15 | 2006-06-15 | 4 | 0d |  |
| 6 | Izrada temeljne ploce | 10d | 2006-06-16 | 2006-06-29 | 5 | 0d |  |
| 7 | Izrada stubova podruma-1.takta | 2d | 2006-06-30 | 2006-07-03 | 6 | 0d |  |
| 8 | Izrada stubova podruma-2.takta | 2d | 2006-07-04 | 2006-07-05 | 7 | 0d |  |
| 9 | Izrada stubova podruma-3.takta | 2d | 2006-07-06 | 2006-07-07 | 8 | 18d | 0d |
| 10 | Izrada stubova podruma-4.takta | 2d | 2006-07-10 | 2006-07-11 | 9 | 18d | 1d |
| 11 | Medjus.kons.podruma-1.takt | 5d | 2006-07-10 | 2006-07-14 | 8FS+2d | 0d |  |
| 12 | Medjus.kons.podruma-2.takt | 5d | 2006-07-17 | 2006-07-21 | 10FS+2d, 11 | 17d | 0d |
| 13 | Izrada stubova prizemlja-1.takta | 2d | 2006-07-17 | 2006-07-18 | 10, 11 | 17d | 0d |
| 14 | Izrada stubova prizemlja-2.takta | 2d | 2006-07-19 | 2006-07-20 | 13 | 17d | 0d |
| 15 | Izrda stubova prizemlja-3.takta | 2d | 2006-07-24 | 2006-07-25 | 12, 14 | 17d | 0d |
| 16 | Izrada stubova prizemlja-4.takta | 2d | 2006-07-26 | 2006-07-27 | 15 | 17d | 2d |
| 17 | Medjus.kons.prizemlja-1.takt | 5d | 2006-07-25 | 2006-07-31 | 14FS+2d | 17d | 0d |
| 18 | Medjus.kons.prizemlja-2.takt | 5d | 2006-08-24 | 2006-08-30 | 11FS+28d, 16FS+2d, 17 | 0d |  |
| 19 | Stubovi 1.sprata-1.takta | 2d | 2006-08-01 | 2006-08-02 | 16, 17 | 34d | 0d |
| 20 | Stubovi 1.sprata-2.takta | 2d | 2006-08-03 | 2006-08-04 | 19 | 34d | 16d |
| 21 | Stubovi 1.sprata-3.takta | 2d | 2006-08-31 | 2006-09-01 | 18, 20 | 17d | 0d |
| 22 | Stubovi 1.sprata-4.takta | 2d | 2006-09-04 | 2006-09-05 | 21 | 17d | 0d |
| 23 | Medjus.kons.1.sprata-1.takta | 5d | 2006-08-31 | 2006-09-06 | 12FS+28d, 20FS+2d | 18d | 0d |
| 24 | Medjus.kons.1.sprata-2.takta | 5d | 2006-09-08 | 2006-09-14 | 17FS+28d, 22FS+2d, 23 | 17d | 0d |
| 25 | Stubovi 2.sprata -1.takta | 2d | 2006-09-07 | 2006-09-08 | 22, 23 | 63d | 0d |
| 26 | Stubovi 2.sprata -2.takta | 2d | 2006-09-11 | 2006-09-12 | 25 | 63d | 2d |
| 27 | Stubovi 2.sprata -3.takta | 2d | 2006-09-15 | 2006-09-18 | 24, 26 | 62d | 0d |
| 28 | Stubovi 2.sprata-4.takta | 2d | 2006-09-19 | 2006-09-20 | 27 | 62d | 16d |
| 29 | Medjus.kons.2.sprata-1.takta | 5d | 2006-10-10 | 2006-10-16 | 18FS+28d, 26FS+2d | 46d | 0d |
| 30 | Medjus.kons.2.sprata-2.takta | 5d | 2006-10-17 | 2006-10-23 | 23FS+28d, 28FS+2d, 29 | 46d | 0d |
| 31 | Izrada krova | 12d | 2006-10-24 | 2006-11-08 | 30 | 95d | 21d |
| 32 | Pregr. zidovi podruma-1.takta | 10d | 2006-08-31 | 2006-09-13 | 12FS+28d, 18 | 18d | 0d |
| 33 | Preg.zidovi podruma -2.takta | 10d | 2006-10-10 | 2006-10-23 | 18FS+28d, 24, 32 | 0d |  |
| 34 | Pregr.zid.podruma-3.takta | 10d | 2006-10-24 | 2006-11-06 | 30, 33 | 46d | 0d |
| 35 | Preg.zid. Podruma -4.takta | 10d | 2006-12-01 | 2006-12-14 | 24FS+28d, 30FS+28d, 34 | 46d | 0d |
| 36 | Instal. rad. Podruma | 10d | 2006-09-14 | 2006-09-27 | 32 | 18d |  |
| 37 | Instal.rad.Prizemlja | 10d | 2006-10-24 | 2006-11-06 | 33, 36 | 0d |  |
| 38 | Instal.radovi 1.sprata | 10d | 2006-11-07 | 2006-11-20 | 34, 37 | 46d | 10d |
| 39 | Instal.radovi 2.sprata | 10d | 2006-12-15 | 2006-12-28 | 35, 38 | 46d | 0d |
| 40 | Malterisanje podruma | 10d | 2006-11-02 | 2006-11-15 | 36SS+7d, 37SS+7d | 0d |  |
| 41 | Malterisanje prizemlja | 10d | 2006-11-16 | 2006-11-29 | 40 | 18d | 0d |
| 42 | Maletrisanje 1.sprata | 10d | 2006-11-30 | 2006-12-13 | 38SS+7d, 41 | 36d | 8d |
| 43 | Malterisanje 2.sprata | 10d | 2006-12-26 | 2007-01-08 | 39SS+7d, 42 | 46d | 0d |
| 44 | Zan. I zavrsni radovi- podruma | 28d | 2006-11-16 | 2006-12-25 | 40 | 0d |  |
| 45 | Zan, I zavrsni radovi- prizemlja | 28d | 2006-12-26 | 2007-02-01 | 41, 44 | 0d |  |
| 46 | Zan. I zavrsni radovi -1.sprata | 28d | 2007-02-02 | 2007-03-13 | 42, 45 | 0d |  |
| 47 | Zan. I zavrsni radovi -2.sprata | 28d | 2007-03-14 | 2007-04-20 | 43, 46 | 0d |  |
| 48 | Izrada fasade | 22d | 2006-12-08 | 2007-01-08 | 31, 43FF | 74d |  |
| 49 | Tehnicki pregled | 5d | 2007-04-23 | 2007-04-27 | 47, 48 | 0d |  |
