# Project1-Novak.mpp-Vezba 2

Schedule from MS Project, 2006-06-01 to 2007-04-27, costs in e.
GRF

## Calendars

- Standard: Mon-Fri 08:00-12:00, 13:00-17:00; Sat-Sun off.

## Resources

| Resource | Unit | Rate |
| --- | --- | --- |
| Bager |  |  |
| Kamion kiper |  | 85 |
| Buldozer |  | 222 |
| Radnici | m3 | 8.33 |

## Schedule

| ID | Task | Duration | Start | Finish | Predecessors | Total slack | Free slack | Resources | Work | Cost |
| --- | --- | --- | --- | --- | --- | --- | --- | --- | --- | --- |
| 1 | Formiranje gradilista | 5d | 2006-06-01 | 2006-06-07 |  | 0d |  | Radnici [4 m3] | 160h | 1,572.8 |
| 2 | Siroki iskop za temeljnu plocu | 3d | 2006-06-08 | 2006-06-12 | 1 | 0d |  | Bager; Buldozer [300%]; Radnici [15 m3]; Kamion kiper [1100%] | 720h | 49,822.8 |
| 3 | Izrada tampon sloja | 1d | 2006-06-13 | 2006-06-13 | 2 | 0d |  | Radnici [5 m3] | 40h | 1,053.2 |
| 4 | Izrada sloja mrsavog betona | 1d | 2006-06-14 | 2006-06-14 | 3 | 0d |  | Radnici [6 m3] | 48h | 919.84 |
| 5 | Postavljanje hidroizolacije | 1d | 2006-06-15 | 2006-06-15 | 4 | 0d |  | Radnici [4 m3] | 32h | 666.56 |
| 6 | Izrada temeljne ploce | 10d | 2006-06-16 | 2006-06-29 | 5 | 0d |  | Radnici [10 m3] | 800h | 7,464 |
| 7 | Izrada stubova podruma-1.takta | 2d | 2006-06-30 | 2006-07-03 | 6 | 0d |  | Radnici [8 m3] | 128h | 1,466.24 |
| 8 | Izrada stubova podruma-2.takta | 2d | 2006-07-04 | 2006-07-05 | 7 | 0d |  | Radnici [8 m3] | 128h | 1,466.24 |
| 9 | Izrada stubova podruma-3.takta | 2d | 2006-07-06 | 2006-07-07 | 8 | 18d | 0d | Radnici [8 m3] | 128h | 1,466.24 |
| 10 | Izrada stubova podruma-4.takta | 2d | 2006-07-10 | 2006-07-11 | 9 | 18d | 1d | Radnici [8 m3] | 128h | 1,466.24 |
| 11 | Medjus.kons.podruma-1.takt | 5d | 2006-07-10 | 2006-07-14 | 8FS+2d | 0d |  | Radnici [10 m3] | 400h | 4,132 |
| 12 | Medjus.kons.podruma-2.takt | 5d | 2006-07-17 | 2006-07-21 | 10FS+2d, 11 | 17d | 0d | Radnici [10 m3] | 400h | 4,132 |
| 13 | Izrada stubova prizemlja-1.takta | 2d | 2006-07-17 | 2006-07-18 | 10, 11 | 17d | 0d | Radnici [8 m3] | 128h | 1,466.24 |
| 14 | Izrada stubova prizemlja-2.takta | 2d | 2006-07-19 | 2006-07-20 | 13 | 17d | 0d | Radnici [8 m3] | 128h | 1,466.24 |
| 15 | Izrda stubova prizemlja-3.takta | 2d | 2006-07-24 | 2006-07-25 | 12, 14 | 17d | 0d | Radnici [8 m3] | 128h | 1,466.24 |
| 16 | Izrada stubova prizemlja-4.takta | 2d | 2006-07-26 | 2006-07-27 | 15 | 17d | 2d | Radnici [8 m3] | 128h | 1,466.24 |
| 17 | Medjus.kons.prizemlja-1.takt | 5d | 2006-07-25 | 2006-07-31 | 14FS+2d | 17d | 0d | Radnici [10 m3] | 400h | 4,132 |
| 18 | Medjus.kons.prizemlja-2.takt | 5d | 2006-08-24 | 2006-08-30 | 11FS+28d, 16FS+2d, 17 | 0d |  | Radnici [10 m3] | 400h | 4,132 |
| 19 | Stubovi 1.sprata-1.takta | 2d | 2006-08-01 | 2006-08-02 | 16, 17 | 34d | 0d | Radnici [8 m3] | 128h | 1,466.24 |
| 20 | Stubovi 1.sprata-2.takta | 2d | 2006-08-03 | 2006-08-04 | 19 | 34d | 16d | Radnici [8 m3] | 128h | 1,466.24 |
| 21 | Stubovi 1.sprata-3.takta | 2d | 2006-08-31 | 2006-09-01 | 18, 20 | 17d | 0d | Radnici [8 m3] | 128h | 1,466.24 |
| 22 | Stubovi 1.sprata-4.takta | 2d | 2006-09-04 | 2006-09-05 | 21 | 17d | 0d | Radnici [8 m3] | 128h | 1,466.24 |
| 23 | Medjus.kons.1.sprata-1.takta | 5d | 2006-08-31 | 2006-09-06 | 12FS+28d, 20FS+2d | 18d | 0d | Radnici [10 m3] | 400h | 4,132 |
| 24 | Medjus.kons.1.sprata-2.takta | 5d | 2006-09-08 | 2006-09-14 | 17FS+28d, 22FS+2d, 23 | 17d | 0d | Radnici [10 m3] | 400h | 4,132 |
| 25 | Stubovi 2.sprata -1.takta | 2d | 2006-09-07 | 2006-09-08 | 22, 23 | 63d | 0d | Radnici [8 m3] | 128h | 1,466.24 |
| 26 | Stubovi 2.sprata -2.takta | 2d | 2006-09-11 | 2006-09-12 | 25 | 63d | 2d | Radnici [8 m3] | 128h | 1,466.24 |
| 27 | Stubovi 2.sprata -3.takta | 2d | 2006-09-15 | 2006-09-18 | 24, 26 | 62d | 0d | Radnici [8 m3] | 128h | 1,466.24 |
| 28 | Stubovi 2.sprata-4.takta | 2d | 2006-09-19 | 2006-09-20 | 27 | 62d | 16d | Radnici [8 m3] | 128h | 1,466.24 |
| 29 | Medjus.kons.2.sprata-1.takta | 5d | 2006-10-10 | 2006-10-16 | 18FS+28d, 26FS+2d | 46d | 0d | Radnici [10 m3] | 400h | 4,132 |
| 30 | Medjus.kons.2.sprata-2.takta | 5d | 2006-10-17 | 2006-10-23 | 23FS+28d, 28FS+2d, 29 | 46d | 0d | Radnici [10 m3] | 400h | 4,132 |
| 31 | Izrada krova | 12d | 2006-10-24 | 2006-11-08 | 30 | 95d | 21d | Radnici [8 m3] | 768h | 8,997.44 |
| 32 | Pregr. zidovi podruma-1.takta | 10d | 2006-08-31 | 2006-09-13 | 12FS+28d, 18 | 18d | 0d | Radnici [4 m3] | 320h | 2,865.6 |
| 33 | Preg.zidovi podruma -2.takta | 10d | 2006-10-10 | 2006-10-23 | 18FS+28d, 24, 32 | 0d |  | Radnici [4 m3] | 320h | 2,865.6 |
| 34 | Pregr.zid.podruma-3.takta | 10d | 2006-10-24 | 2006-11-06 | 30, 33 | 46d | 0d | Radnici [4 m3] | 320h | 2,865.6 |
| 35 | Preg.zid. Podruma -4.takta | 10d | 2006-12-01 | 2006-12-14 | 24FS+28d, 30FS+28d, 34 | 46d | 0d | Radnici [4 m3] | 320h | 2,865.6 |
| 36 | Instal. rad. Podruma | 10d | 2006-09-14 | 2006-09-27 | 32 | 18d |  | Radnici [5 m3] | 400h | 8,552 |
| 37 | Instal.rad.Prizemlja | 10d | 2006-10-24 | 2006-11-06 | 33, 36 | 0d |  | Radnici [5 m3] | 400h | 8,552 |
| 38 | Instal.radovi 1.sprata | 10d | 2006-11-07 | 2006-11-20 | 34, 37 | 46d | 10d | Radnici [5 m3] | 400h | 8,552 |
| 39 | Instal.radovi 2.sprata | 10d | 2006-12-15 | 2006-12-28 | 35, 38 | 46d | 0d | Radnici [5 m3] | 400h | 8,552 |
| 40 | Malterisanje podruma | 10d | 2006-11-02 | 2006-11-15 | 36SS+7d, 37SS+7d | 0d |  | Radnici [4 m3] | 320h | 2,825.6 |
| 41 | Malterisanje prizemlja | 10d | 2006-11-16 | 2006-11-29 | 40 | 18d | 0d | Radnici [4 m3] | 320h | 2,825.6 |
| 42 | Maletrisanje 1.sprata | 10d | 2006-11-30 | 2006-12-13 | 38SS+7d, 41 | 36d | 8d | Radnici [4 m3] | 320h | 2,825.6 |
| 43 | Malterisanje 2.sprata | 10d | 2006-12-26 | 2007-01-08 | 39SS+7d, 42 | 46d | 0d | Radnici [4 m3] | 320h | 2,825.6 |
| 44 | Zan. I zavrsni radovi- podruma | 28d | 2006-11-16 | 2006-12-25 | 40 | 0d |  | Radnici [5 m3] | 1120h | 10,369.6 |
| 45 | Zan, I zavrsni radovi- prizemlja | 28d | 2006-12-26 | 2007-02-01 | 41, 44 | 0d |  | Radnici [5 m3] | 1120h | 10,369.6 |
| 46 | Zan. I zavrsni radovi -1.sprata | 28d | 2007-02-02 | 2007-03-13 | 42, 45 | 0d |  | Radnici [5 m3] | 1120h | 10,369.6 |
| 47 | Zan. I zavrsni radovi -2.sprata | 28d | 2007-03-14 | 2007-04-20 | 43, 46 | 0d |  | Radnici [5 m3] | 1120h | 10,369.6 |
| 48 | Izrada fasade | 22d | 2006-12-08 | 2007-01-08 | 31, 43FF | 74d |  | Radnici [6 m3] | 1056h | 14,796.48 |
| 49 | Tehnicki pregled | 5d | 2007-04-23 | 2007-04-27 | 47, 48 | 0d |  | Radnici [4 m3] | 160h | 1,572.8 |
