Schedule from MS Project, 2004-10-11 to 2005-12-19.

## Calendars

- Standard: Mon-Fri 08:00-12:00, 13:00-17:00; Sat-Sun off.

## Schedule

| ID | Task | Duration | Start | Finish | Predecessors | Total slack | Free slack |
| --- | --- | --- | --- | --- | --- | --- | --- |
| 1 | dopremanje mehanizacije | 1d | 2004-10-11 | 2004-10-11 |  | 0d |  |
| 2 | izrada zemljanog prilaznog puta | 8d | 2004-10-12 | 2004-10-21 | 1 | 0d |  |
| 3 | formiranje gradilista | 4d | 2004-11-01 | 2004-11-04 | 2SS+14d | 0d |  |
| 4 | iskop za temelj 1 stuba | 12d | 2004-11-05 | 2004-11-22 | 2, 3 | 0d |  |
| 5 | iskop za temelj 2 stuba | 15d | 2004-11-23 | 2004-12-13 | 4 | 31d | 0d |
| 6 | iskop za temelj 3 stuba | 15d | 2004-12-14 | 2005-01-03 | 5 | 61d | 0d |
| 7 | iskop za temelj 4 stuba | 12d | 2005-01-04 | 2005-01-19 | 6 | 90d | 22d |
| 8 | izrada temelja 1 stuba | 24d | 2004-11-23 | 2004-12-24 | 4 | 0d |  |
| 9 | izrada temelja 2 stuba | 20d | 2004-12-27 | 2005-01-21 | 5, 8 | 22d | 0d |
| 10 | izrada temelja 3 stuba | 20d | 2005-01-24 | 2005-02-18 | 6, 9 | 47d | 0d |
| 11 | izrada temelja 4 stuba | 24d | 2005-02-21 | 2005-03-24 | 7, 10 | 68d |  |
| 12 | izrada 1 stuba | 42d | 2004-12-27 | 2005-02-22 | 8 | 0d |  |
| 13 | izrada 2 stuba | 45d | 2005-02-23 | 2005-04-26 | 9, 12 | 0d |  |
| 14 | izrada 3 stuba | 45d | 2005-04-27 | 2005-06-28 | 10, 13 | 0d |  |
| 15 | izrada 4 stuba | 42d | 2005-06-29 | 2005-08-25 | 11, 14 | 0d |  |
| 16 | izrada nosaca mosta 1 polja | 11d | 2004-11-12 | 2004-11-26 | 4SS+5d | 142d | 0d |
| 17 | izrada nosaca mosta 2 polja | 11d | 2004-11-29 | 2004-12-13 | 16 | 153d | 0d |
| 18 | izrada nosaca mosta 3 polja | 11d | 2004-12-14 | 2004-12-28 | 17 | 164d | 0d |
| 19 | prednaprezanje nosaca 1 polja | 2d | 2005-01-06 | 2005-01-07 | 16FS+28d | 142d | 0d |
| 20 | prednaprezanje nosaca 2 polja | 2d | 2005-01-21 | 2005-01-24 | 17FS+28d, 19 | 153d | 0d |
| 21 | prednaprezanje nosaca 3 polja | 2d | 2005-02-07 | 2005-02-08 | 18FS+28d, 20 | 164d | 0d |
| 22 | transport nosaca 1 polja | 2d | 2005-01-14 | 2005-01-17 | 19FS+4d | 142d | 9d |
| 23 | transport nosaca 2 polja | 2d | 2005-01-31 | 2005-02-01 | 20FS+4d, 22 | 153d | 9d |
| 24 | transport nosaca 3 polja | 2d | 2005-02-15 | 2005-02-16 | 21FS+4d, 23 | 164d |  |
| 25 | montaza nosaca 1 polja | 6d | 2005-06-06 | 2005-06-13 | 13FS+28d, 22 | 43d | 0d |
| 26 | montaza nosaca 2 polja | 6d | 2005-08-08 | 2005-08-15 | 14FS+28d, 23, 25 | 20d | 0d |
| 27 | montaza nosaca 3 polja | 6d | 2005-10-05 | 2005-10-12 | 15FS+28d, 24, 26 | 0d |  |
| 28 | izrada kolovozne ploce 1 polja | 22d | 2005-06-14 | 2005-07-13 | 25 | 43d | 23d |
| 29 | izrada kolovozne ploce 2 polja | 22d | 2005-08-16 | 2005-09-14 | 26, 28 | 20d |  |
| 30 | izrada kolovozne ploce 3 polja | 22d | 2005-10-13 | 2005-11-11 | 27, 29 | 0d |  |
| 31 | montaza ograde | 10d | 2005-11-04 | 2005-11-17 | 30FF+4d | 17d |  |
| 32 | asfaltiranje kolovoza | 6d | 2005-12-05 | 2005-12-12 | 30FS+15d | 0d |  |
| 33 | tehnicki pregled | 5d | 2005-12-13 | 2005-12-19 | 31, 32 | 0d |  |
