Schedule from MS Project, 2005-03-01 to 2007-05-21.
GRF

## Calendars

- Standard: Mon-Fri 08:00-12:00, 13:00-17:00; Sat-Sun off.

## Schedule

| ID | Task | Duration | Start | Finish | Predecessors | Total slack | Free slack |
| --- | --- | --- | --- | --- | --- | --- | --- |
| 1 | formiranje gradilista | 10d | 2005-03-01 | 2005-03-14 |  | 0d |  |
| 2 | organizacija gradi. | 10d | 2005-03-15 | 2005-03-28 | 1 | 0d |  |
| 3 | iskop useka | 21d | 2005-03-29 | 2005-04-26 | 1, 2SS+10d | 0d |  |
| 4 | iskop za temelje1 | 10d | 2005-04-27 | 2005-05-10 | 3 | 0d |  |
| 5 | iskop za temelje2 | 36d | 2005-05-11 | 2005-06-29 | 4 | 19d | 0d |
| 6 | iskop za temelje3 | 36d | 2005-06-30 | 2005-08-18 | 5 | 139d | 0d |
| 7 | iskop za temelje4 | 10d | 2005-08-19 | 2005-09-01 | 6 | 285d |  |
| 8 | izrada za temelj stuba 1 | 20d | 2005-05-11 | 2005-06-07 | 4 | 0d |  |
| 9 | izrada za temelj stuba 2 | 48d | 2005-07-27 | 2005-09-30 | 5, 8, 12 | 0d |  |
| 10 | izrada za temelj stuba 3 | 48d | 2006-03-02 | 2006-05-08 | 6, 9, 13 | 0d |  |
| 11 | izrada za temelj stuba 4 | 20d | 2006-10-06 | 2006-11-02 | 7, 10, 14 | 0d |  |
| 12 | izrada stuba mosta 1 | 35d | 2005-06-08 | 2005-07-26 | 8 | 0d |  |
| 13 | izrada stuba mosta 2 | 108d | 2005-10-03 | 2006-03-01 | 9, 12 | 0d |  |
| 14 | izrada stuba mosta 3 | 108d | 2006-05-09 | 2006-10-05 | 10, 13 | 0d |  |
| 15 | izrada stuba mosta 4 | 35d | 2006-11-03 | 2006-12-21 | 11, 14 | 0d |  |
| 16 | prefabrika. Kolovoznih AB nosaca za raspon 1 | 17d | 2005-05-04 | 2005-05-26 | 4SS+5d | 328d | 0d |
| 17 | prefabrika. Kolovoznih AB nosaca za raspon 2 | 17d | 2005-05-27 | 2005-06-20 | 16 | 345d | 0d |
| 18 | prefabrika. Kolovoznih AB nosaca za raspon 3 | 17d | 2005-06-21 | 2005-07-13 | 17 | 362d | 0d |
| 19 | predhodno naprezanje nosaca za raspon 1 | 1d | 2005-07-06 | 2005-07-06 | 16FS+28d | 328d | 0d |
| 20 | predhodno naprezanje nosaca za raspon 2 | 1d | 2005-07-29 | 2005-07-29 | 17FS+28d, 19 | 345d | 0d |
| 21 | predhodno naprezanje nosaca za raspon 3 | 1d | 2005-08-23 | 2005-08-23 | 18FS+28d, 20 | 362d | 0d |
| 22 | dopremanje kolovoznih nosaca za raspon 1 | 1d | 2005-07-25 | 2005-07-25 | 19FS+12d | 328d | 0d |
| 23 | dopremanje kolovoznih nosaca za raspon 2 | 1d | 2005-08-17 | 2005-08-17 | 20FS+12d, 22 | 345d | 16d |
| 24 | dopremanje kolovoznih nosaca za raspon 3 | 1d | 2005-09-09 | 2005-09-09 | 21FS+12d, 23 | 362d |  |
| 25 | montaza kolovoznih nosaca za raspon 1 | 5d | 2005-07-26 | 2005-08-01 | 22 | 328d | 0d |
| 26 | montaza kolovoznih nosaca za raspon 2 | 5d | 2006-11-15 | 2006-11-21 | 14FS+28d, 23, 25 | 21d | 0d |
| 27 | montaza kolovoznih nosaca za raspon 3 | 5d | 2007-01-31 | 2007-02-06 | 15FS+28d, 24, 26 | 0d |  |
| 28 | izrada kolovozne ploce 1 | 34d | 2005-08-02 | 2005-09-16 | 25 | 328d | 307d |
| 29 | izrada kolovozne ploce 2 | 34d | 2006-11-22 | 2007-01-08 | 26, 28 | 21d |  |
| 30 | izrada kolovozne ploce 3 | 34d | 2007-02-07 | 2007-03-26 | 27, 29 | 0d |  |
| 31 | montaza ograde | 10d | 2007-03-29 | 2007-04-11 | 28, 29, 30FF+12d | 5d |  |
| 32 | asfaltiranje kolovoza | 5d | 2007-04-17 | 2007-04-23 | 30FS+15d, 31FF+3d | 0d |  |
| 33 | zavrsni radovi I ciscenje | 4d | 2007-04-24 | 2007-04-27 | 32 | 0d |  |
| 34 | tehnicki pregled | 12d | 2007-04-30 | 2007-05-15 | 33 | 0d |  |
| 35 | zatvaranje gradilista | 4d | 2007-05-16 | 2007-05-21 | 34 | 0d |  |
