# tehnicki pregled I primopredaja objekta

Schedule from MS Project, 2003-09-02 to 2004-05-21, costs in $.
n

## Calendars

- Kalendar Hale: Mon-Sat 08:00-12:00, 13:00-17:00; Sun off.

## Resources

| Resource | Rate |
| --- | --- |
| bager | 330 |
| radnik | 320 |
| automesalica | 22 |

## Schedule

| ID | Task | Duration | Start | Finish | Predecessors | Total slack | Free slack | Resources | Work | Cost |
| --- | --- | --- | --- | --- | --- | --- | --- | --- | --- | --- |
| 1 | formiranje gradilista | 12d | 2003-09-02 | 2003-09-15 |  | 125d | 0d | radnik [800%]; automesalica | 720h | 206,560 |
| 2 | pripremni radovi | 5d | 2003-09-16 | 2003-09-20 | 1 | 125d | 0d | radnik [600%] | 192h | 61,440 |
| 3 | iskop za podnu plocu za halu 1 | 3d | 2003-09-22 | 2003-09-24 | 2 | 125d | 0d | bager; radnik [600%] | 112h | 36,000 |
| 4 | iskop za podnu plocu za halu 2 | 2d | 2003-09-25 | 2003-09-26 | 3 | 125d | 0d | bager; radnik [600%] | 112h | 36,000 |
| 5 | iskop za podnu plocu za halu 3 | 3d | 2003-09-27 | 2003-09-30 | 4 | 172d | 0d | bager; radnik [600%] | 112h | 36,000 |
| 6 | iskop za temelje hale 1 | 2d | 2003-09-25 | 2003-09-26 | 3 | 125d | 0d | bager; radnik [1000%] | 176h | 56,480 |
| 7 | iskop za temelje hale 2 | 3d | 2003-09-27 | 2003-09-30 | 4, 6 | 125d | 0d | bager; radnik [1000%] | 176h | 56,480 |
| 8 | iskop za temelje hale 3 | 3d | 2003-10-01 | 2003-10-03 | 5, 7 | 172d | 0d | bager; radnik [1000%] | 176h | 56,480 |
| 9 | izrada temelja samca 1 | 3d | 2003-09-27 | 2003-09-30 | 6 | 162d | 0d | automesalica; radnik [500%]; bager [150%] | 120h | 33,872 |
| 10 | izrada temelja samca 2 | 3d | 2003-10-01 | 2003-10-03 | 9 | 163d | 0d | radnik [500%]; automesalica | 96h | 25,952 |
| 11 | izrada temelja samca 3 | 3d | 2003-10-04 | 2003-10-07 | 8, 10 | 172d | 5d | radnik [500%]; automesalica; bager | 112h | 31,232 |
| 12 | prefabrikacija AB stubova za halu 1 | 15d | 2003-10-01 | 2003-10-17 | 2, 7 | 125d | 0d | radnik [1200%] | 1152h | 368,640 |
| 13 | prefabrikacija AB stubova za halu2 | 15d | 2003-10-18 | 2003-11-04 | 12 | 125d | 0d | radnik [1200%] | 1152h | 368,640 |
| 14 | prefabrikacija AB stubova za halu 3 | 15d | 2003-11-05 | 2003-11-21 | 13 | 125d | 0d | radnik [1200%] | 1152h | 368,640 |
| 15 | dopremanje stubova na gradiliste hala 1 | 2d | 2003-11-20 | 2003-11-21 | 12FS+28d | 141d | 0d | radnik [400%] | 64h | 20,480 |
| 16 | dopremanje stubova na gradiliste hala 2 | 2d | 2003-12-08 | 2003-12-09 | 13FS+28d, 15 | 141d |  | radnik [400%] | 64h | 20,480 |
| 17 | dopremanje stubova na gradiliste hala 3 | 3d | 2003-12-25 | 2003-12-27 | 14FS+28d | 125d |  | radnik [400%] | 64h | 20,480 |
| 18 | montaza stubova hale 1 | 7d | 2003-12-02 | 2003-12-09 | 15FS+8d | 141d |  | radnik [400%] | 192h | 61,440 |
| 19 | montaza stubova hale 2 | 7d | 2003-10-06 | 2003-10-13 | 2, 9SS+7d, 10 | 162d | 0d | radnik [400%] | 192h | 61,440 |
| 20 | montaza stubova hale 3 | 8d | 2003-10-14 | 2003-10-22 | 11, 19 | 167d | 5d | radnik [400%] | 192h | 61,440 |
| 21 | izrada celicnih resetki za halu 1 | 22d | 2003-10-01 | 2003-10-25 | 9 | 179d | 0d | radnik [600%] | 576h | 184,320 |
| 22 | izrada celicnih resetki za halu 2 | 15d | 2003-10-11 | 2003-10-28 | 19SS+5d | 162d | 0d | radnik [600%] | 576h | 184,320 |
| 23 | izrada celicnih resetki za halu 3 | 15d | 2003-10-29 | 2003-11-14 | 20, 22 | 162d |  | radnik [600%] | 576h | 184,320 |
| 24 | dopremanje resetki za halu 1 | 2d | 2003-09-02 | 2003-09-03 |  | 224d |  | radnik [400%] | 64h | 20,480 |
| 25 | dopremanje resetki za halu 2 | 3d | 2003-10-29 | 2003-10-31 | 22 | 174d |  | radnik [400%] | 64h | 20,480 |
| 26 | dopremanje resetki za halu 3 | 2d | 2003-09-02 | 2003-09-03 |  | 224d |  | radnik [400%] | 64h | 20,480 |
| 27 | montiranje resetki u hali 1 | 3d | 2003-09-02 | 2003-09-04 |  | 223d |  | radnik [600%] | 144h | 46,080 |
| 28 | montiranje resetki u hali 2 | 3d | 2003-09-02 | 2003-09-04 |  | 223d |  | radnik [600%] | 144h | 46,080 |
| 29 | montiranje resetki u hali 3 | 3d | 2003-09-02 | 2003-09-04 |  | 223d |  | radnik [600%] | 144h | 46,080 |
| 30 | postavljanje krovnog pokrivaca hala 1 | 12d | 2003-10-07 | 2003-10-20 | 21SS+5d | 184d |  | radnik [1400%] | 1120h | 358,400 |
| 31 | postavljanje krovnog pokrivaca hala 2 | 226d | 2003-09-02 | 2004-05-21 |  | 0d |  | radnik [1400%] | 2240h | 716,800 |
| 32 | postavljanje krovnog pokrivaca hala 3 | 12d | 2003-09-02 | 2003-09-15 |  | 207d | 0d | radnik [1400%] | 1120h | 358,400 |
| 33 | izvodjenje podne ploca hala 1 | 2d | 2003-09-22 | 2003-09-23 | 32FS+5d | 207d |  | radnik [1000%]; automesalica | 176h | 51,552 |
| 34 | izvodjenje podne ploca hala 2 | 2d | 2003-09-02 | 2003-09-03 |  | 224d |  | radnik [1000%]; automesalica | 176h | 51,552 |
| 35 | izvodjenje podne ploca hala 3 | 2d | 2003-09-02 | 2003-09-03 |  | 224d |  | radnik [1000%]; automesalica | 176h | 51,552 |
| 36 | postavljanje zidnih panela hala 1 | 12d | 2003-09-02 | 2003-09-15 |  | 214d |  | radnik [1400%] | 1120h | 358,400 |
| 37 | postavljanje zidnih panela hala 2 | 12d | 2003-09-02 | 2003-09-15 |  | 214d |  | radnik [1400%] | 1120h | 358,400 |
| 38 | postavljanje zidnih panela hala 3 | 12d | 2003-09-02 | 2003-09-15 |  | 214d |  | radnik [1400%] | 1120h | 358,400 |
| 39 | tehnicki pregled I primopredaja objekta | 4d | 2003-09-02 | 2003-09-05 |  | 222d |  | radnik [400%] | 128h | 40,960 |
